# CSF Upgrades and Migrations

Schedule from MS Project, 2013-01-14 to 2013-06-14, A marks actual dates.
MIT

## Calendars

- Standard: Mon-Fri 08:00-12:00, 13:00-17:00; Sat-Sun off.

## Resources

| Resource |
| --- |
| Dave |
| René |
| Steve |
| Felicia |
| Ram |
| Kevin |
| Brian |
| Janet |
| Seth |
| Lee |
| Faith |
| Peter |
| Debra |

## Schedule

| ID | WBS | Task | Type | Duration | Start | Finish | Predecessors | Complete | Remaining | Baseline start | Baseline finish | Baseline duration | Total slack | Free slack | Resources | Work | Actual work |
| --- | --- | --- | --- | --- | --- | --- | --- | --- | --- | --- | --- | --- | --- | --- | --- | --- | --- |
| 1 | 1 | Upgrade CSF to 2.0 |  | 10d | 2013-01-14 A | 2013-01-25 A |  | 100% |  |  |  |  |  |  |  |  |  |
| 2 | 2 | **Upgrade of Existing CSF Apps to CSF 2.0** |  | 37d | 2013-02-13 A | 2013-04-04 |  | 97% | 1.25d | 2013-02-13 | 2013-03-08 | 18d? | 51d |  |  | 193.6h | 177.6h |
| 3 | 2.1 | **Development** |  | 11d | 2013-02-13 A | 2013-02-27 A |  | 100% |  | 2013-02-13 | 2013-03-08 | 18d |  |  |  | 64h | 64h |
| 4 | 2.1.1 | Upgrade IAP |  | 7d | 2013-02-14 A | 2013-02-25 A | 1FS+13d | 100% |  | 2013-02-14 | 2013-02-20 | 4d |  |  | Steve [50%] | 28h | 28h |
| 5 | 2.1.2 | Upgrade Subject Evaluation Report/OSE Report |  | 1d | 2013-02-26 A | 2013-02-26 A | 4FS+3d | 100% |  | 2013-02-26 | 2013-03-01 | 4d |  |  | Steve [50%] | 4h | 4h |
| 6 | 2.1.3 | Upgrade Sponsor Billing |  | 4d | 2013-02-13 A | 2013-02-19 A | 1FS+12d | 100% |  | 2013-02-13 | 2013-02-19 | 4d |  |  | Dave [50%] | 16h | 16h |
| 7 | 2.1.4 | Upgrade Survey Engine |  | 2d | 2013-02-26 A | 2013-02-27 A | 6FS+4d | 100% |  | 2013-02-26 | 2013-03-01 | 4d |  |  | Dave [50%] | 8h | 8h |
| 8 | 2.1.5 | Upgrade Response Rate Report |  | 2d | 2013-02-22 A | 2013-02-25 A | 7FS+1d | 100% |  | 2013-03-05 | 2013-03-08 | 4d |  |  | Dave [50%] | 8h | 8h |
| 9 | 2.1.6 | Upgrades complete | milestone | 0d | 2013-02-27 A | 2013-02-27 A | 4, 5, 6, 7, 8 | 100% |  | 2013-03-08 | 2013-03-08 | 0d |  |  | Dave [50%]; Steve [50%] |  |  |
| 10 | 2.2 | **Testing** |  | 30d | 2013-02-20 A | 2013-04-02 A |  | 100% |  |  |  |  |  |  |  | 113.6h | 113.6h |
| 11 | 2.2.1 | **Test Planning** |  | 8d | 2013-02-20 A | 2013-03-01 A |  | 100% |  |  |  |  |  |  |  | 31.6h | 31.6h |
| 12 | 2.2.1.1 | Sponsor Billing |  | 3d | 2013-02-20 A | 2013-02-22 A | 4SS+4d | 100% |  |  |  |  |  |  | Seth [25%]; Faith [25%] | 7.6h | 7.6h |
| 13 | 2.2.1.2 | OSE Applications |  | 3d | 2013-02-27 A | 2013-03-01 A | 12FS+2d | 100% |  |  |  |  |  |  | Lee | 24h | 24h |
| 14 | 2.2.1.3 | Test Planning Complete | milestone | 0d | 2013-03-01 A | 2013-03-01 A | 12, 13 | 100% |  |  |  |  |  |  |  |  |  |
| 15 | 2.2.2 | **BA Testing** |  | 27d | 2013-02-25 A | 2013-04-02 A |  | 100% |  |  |  |  |  |  |  | 82h | 82h |
| 16 | 2.2.2.1 | Sponsor Billing |  | 3d | 2013-02-25 A | 2013-02-27 A | 12 | 100% |  |  |  |  |  |  | Faith [25%] | 6h | 6h |
| 17 | 2.2.2.2 | IAP (includes planning) |  | 22d | 2013-03-04 A | 2013-04-02 A | 16FS+2d | 100% |  |  |  |  |  |  | Seth [25%] | 44h | 44h |
| 18 | 2.2.2.3 | OSE Applications |  | 4d | 2013-03-04 A | 2013-03-07 A | 13 | 100% |  |  |  |  |  |  | Lee | 32h | 32h |
| 19 | 2.2.2.4 | BA Testing Complete | milestone | 0d | 2013-03-28 A | 2013-03-28 A | 16, 18, 17 | 100% |  |  |  |  |  |  |  |  |  |
| 20 | 2.2.3 | **UAT** |  | 4d | 2013-03-04 A | 2013-03-07 A |  | 100% |  |  |  |  |  |  |  |  |  |
| 21 | 2.2.3.1 | OSE Applications |  | 4d | 2013-03-04 A | 2013-03-07 A | 18SS | 100% |  |  |  |  |  |  |  |  |  |
| 22 | 2.2.3.2 | UAT Complete | milestone | 0d | 2013-03-07 A | 2013-03-07 A | 21 | 100% |  |  |  |  |  |  |  |  |  |
| 23 | 2.2.4 | Testing Efforts Complete | milestone | 0d | 2013-03-28 A | 2013-03-28 A | 14, 19, 22 | 100% |  |  |  |  |  |  |  |  |  |
| 24 | 2.3 | **Deployment Preparation** |  | 2d | 2013-04-03 | 2013-04-04 |  |  |  |  |  |  | 51d |  |  | 16h |  |
| 25 | 2.3.1 | Get business approval for IAP |  | 2d | 2013-04-03 | 2013-04-04 | 17 |  |  |  |  |  | 51d | 0d | Seth | 16h |  |

| ID | WBS | Task | Type | Duration | Start | Finish | Predecessors | Complete | Remaining | Baseline start | Baseline finish | Baseline duration | Total slack | Free slack | Resources | Work | Actual work |
| --- | --- | --- | --- | --- | --- | --- | --- | --- | --- | --- | --- | --- | --- | --- | --- | --- | --- |
| 26 | 2.4 | **Go-live** |  | 26d | 2013-02-28 A | 2013-04-04 |  | 99% | 0d |  |  |  | 51d |  |  |  |  |
| 27 | 2.4.1 | Sponsor Billing | milestone | 1d | 2013-02-28 A | 2013-02-28 A | 16FS+2d | 100% |  |  |  |  |  |  |  |  |  |
| 28 | 2.4.2 | IAP | milestone | 0d | 2013-04-04 | 2013-04-04 | 17FS+2d, 25 |  |  |  |  |  | 51d | 0d |  |  |  |
| 29 | 2.4.3 | OSE Applications | milestone | 1d | 2013-03-07 A | 2013-03-08 A | 18, 21 | 100% |  |  |  |  |  |  |  |  |  |
| 30 | 2.5 | Upgrade of Existing CSF Apps to CSF 2.0 Complete | milestone | 0d | 2013-04-04 | 2013-04-04 | 27, 28, 29 |  |  |  |  |  | 51d |  |  |  |  |
| 31 | 3 | **Convert SAIS-Common Apps to CSF 2.0** |  | 50d | 2013-03-22 A | 2013-05-30 |  |  | 50d |  |  |  | 11d |  |  | 72.5h |  |
| 32 | 3.1 | **Batch Admin** |  | 50d | 2013-03-22 A | 2013-05-30 |  |  | 50d |  |  |  | 11d |  |  | 72.5h |  |
| 33 | 3.1.1 | Development |  | 28d | 2013-03-22 A | 2013-05-01 |  |  | 28d |  |  |  | 11d | 0d | Steve [25%] | 56h |  |
| 34 | 3.1.2 | Testing |  | 21d | 2013-05-02 | 2013-05-30 | 33 |  |  |  |  |  | 11d | 0d |  |  |  |
| 35 | 3.1.3 | **Deployment Preparation** |  | 9.25d | 2013-05-16 | 2013-05-29 |  |  |  |  |  |  | 12.75d |  |  | 16.5h |  |
| 36 | 3.1.3.1 | Create deployment plan |  | 7d | 2013-05-16 | 2013-05-24 | 34SS+10d |  |  |  |  |  | 13.75d | 1d | René [25%] | 14h |  |
| 37 | 3.1.3.2 | Review deployment plan with participants |  | 0.25d | 2013-05-28 | 2013-05-28 | 36 |  |  |  |  |  | 12.75d | 0d | René [25%] | 0.5h |  |
| 38 | 3.1.3.3 | Get business approval |  | 1d | 2013-05-28 | 2013-05-29 | 37 |  |  |  |  |  | 12.75d | 1.75d | René [25%] | 2h |  |
| 39 | 3.1.4 | Go-live | milestone | 0d | 2013-05-30 | 2013-05-30 | 38, 34 |  |  |  |  |  | 11d |  |  |  |  |
| 40 | 4 | **PE REG Upgrade** |  | 76d? | 2013-01-14 A | 2013-04-29 |  | 69% | 23.22d? | 2013-02-07 | 2013-03-07 | 21d? | 34d |  |  | 274h | 256h |
| 41 | 4.1 | **Phase I - Java 6, Touchstone, and CSF Enabling** |  | 58d | 2013-02-07 A | 2013-04-29 |  | 75% | 14.72d | 2013-02-07 | 2013-03-07 | 21d? | 34d |  |  | 258h | 256h |
| 42 | 4.1.1 | **Development** |  | 27d | 2013-02-07 A | 2013-03-15 A |  | 100% |  | 2013-02-07 | 2013-03-07 | 21d |  |  |  | 208h | 208h |
| 43 | 4.1.1.1 | Do set-up and configuration required for upgrade |  | 5d | 2013-02-07 A | 2013-02-13 A |  | 100% |  | 2013-02-07 | 2013-02-13 | 5d |  |  | Ram | 40h | 40h |
| 44 | 4.1.1.2 | Perform upgrade |  | 9d | 2013-02-14 A | 2013-02-27 A | 43 | 100% |  | 2013-02-14 | 2013-02-21 | 5d |  |  | Ram | 72h | 72h |
| 45 | 4.1.1.3 | Unit test changes |  | 12d | 2013-02-28 A | 2013-03-15 A | 44 | 100% |  | 2013-02-22 | 2013-03-07 | 10d |  |  | Ram | 96h | 96h |
| 46 | 4.1.2 | **Testing** |  | 48d | 2013-02-20 A | 2013-04-26 |  | 60% | 19.2d |  |  |  | 35d |  |  | 50h | 48h |
| 47 | 4.1.2.1 | Test planning |  | 12d | 2013-02-20 A | 2013-03-07 A | 44SS+4d | 100% |  |  |  |  |  |  | Debra [25%] | 24h | 24h |
| 48 | 4.1.2.2 | QA testing |  | 12d | 2013-03-18 A | 2013-04-02 A | 47, 45 | 100% |  |  |  |  |  |  | Debra [25%] | 24h | 24h |
| 49 | 4.1.2.3 | Load testing |  | 1d | 2013-04-04 | 2013-04-04 | 48FS+1d |  |  |  |  |  | 51d |  | Steve [25%] | 2h |  |
| 50 | 4.1.2.4 | User testing |  | 15d | 2013-04-08 | 2013-04-26 | 48FS+3d |  |  |  |  |  | 34d | 0d |  |  |  |
| 51 | 4.1.3 | Go-live |  | 1d | 2013-04-29 | 2013-04-29 | 50 |  |  |  |  |  | 34d | 0d |  |  |  |

| ID | WBS | Task | Type | Duration | Start | Finish | Predecessors | Complete | Remaining | Baseline start | Baseline finish | Baseline duration | Total slack | Free slack | Constraint | Resources | Work | Actual work |
| --- | --- | --- | --- | --- | --- | --- | --- | --- | --- | --- | --- | --- | --- | --- | --- | --- | --- | --- |
| 52 | 4.2 | **Phase II - Full CSF Upgrade** |  | 47d? | 2013-01-14 | 2013-03-19 |  |  |  |  |  |  | 63d |  |  |  | 16h |  |
| 53 | 4.2.1 | **Development** |  | 2d? | 2013-03-18 | 2013-03-19 |  |  |  |  |  |  | 63d |  |  |  | 16h |  |
| 54 | 4.2.1.1 | Perform full upgrade |  | 1d? | 2013-03-18 | 2013-03-18 | 45 |  |  |  |  |  | 63d | 0d |  | Ram | 8h |  |
| 55 | 4.2.1.2 | Unit test changes |  | 1d? | 2013-03-19 | 2013-03-19 | 54 |  |  |  |  |  | 63d |  |  | Ram | 8h |  |
| 56 | 4.2.2 | **Testing** |  | 1d? | 2013-01-14 | 2013-01-14 |  |  |  |  |  |  | 109d |  |  |  |  |  |
| 57 | 4.2.2.1 | QA |  | 1d? | 2013-01-14 | 2013-01-14 |  |  |  |  |  |  | 109d |  |  |  |  |  |
| 58 | 4.2.2.2 | User |  | 1d? | 2013-01-14 | 2013-01-14 |  |  |  |  |  |  | 109d |  |  |  |  |  |
| 59 | 4.2.3 | Go-live |  | 1d? | 2013-01-14 | 2013-01-14 |  |  |  |  |  |  | 109d | 75d |  |  |  |  |
| 60 | 4.3 | PE REG upgrade complete | milestone | 0d | 2013-04-29 | 2013-04-29 | 51, 59 |  |  |  |  |  | 34d |  |  | Ram |  |  |
| 61 | 5 | **OREG to Conversion to CSF 2.0** |  | 90d | 2013-02-11 A | 2013-06-14 |  | 48% | 46.64d | 2013-02-11 | 2013-05-28 | 76d | 0d |  |  |  | 790h | 424h |
| 62 | 5.1 | **Development (including unit testing)** |  | 37d | 2013-02-11 A | 2013-04-02 A |  | 100% |  | 2013-02-11 | 2013-03-22 | 29d |  |  |  |  | 400h | 400h |
| 63 | 5.1.1 | Phase 1 - Required as-is , high priority (A/D and OREG) |  | 9d | 2013-02-11 A | 2013-02-22 A |  | 100% |  |  |  |  |  |  | start no earlier than 2013-02-11 | Felicia | 72h | 72h |
| 64 | 5.1.2 | Phase 2 - Medium priority validation and messaging |  | 18d | 2013-02-25 A | 2013-03-20 A | 63 | 100% |  |  |  |  |  |  |  | Felicia | 144h | 144h |
| 65 | 5.1.3 | Phase 3 - Stabilize JAR and rafactor CSF dependencies |  | 8d | 2013-03-13 A | 2013-03-22 A | 64FS-6d | 100% |  |  |  |  |  |  |  | Felicia | 64h | 64h |
| 66 | 5.1.4 | Phase 4 - Modify OREG to use new JAR and upgrade to CSF 2.0 |  | 15d | 2013-03-13 A | 2013-04-02 A | 65SS | 100% |  |  |  |  |  |  |  | Felicia | 120h | 120h |
| 67 | 5.1.5 | OREG conversion development complete | milestone | 0d | 2013-04-02 A | 2013-04-02 A | 66 | 100% |  |  |  |  |  |  |  | Felicia |  |  |
| 68 | 5.2 | Regression Testing |  | 24d | 2013-04-01 A | 2013-05-03 | 67FS-2d | 13% | 21d | 2013-03-25 | 2013-04-26 | 24d | 17d | 0d |  | Kevin | 192h | 24h |
| 69 | 5.3 | UAT |  | 15d | 2013-04-29 | 2013-05-17 | 68FS-5d |  |  | 2013-04-29 | 2013-05-24 | 20d | 17d | 0d |  | Peter [25%] | 30h |  |
| 70 | 5.4 | **Deployment Preparation** |  | 11d | 2013-04-29 | 2013-05-13 |  |  |  |  |  |  | 24d |  |  |  | 88h |  |
| 71 | 5.4.1 | Create deployment plan |  | 5d | 2013-04-29 | 2013-05-03 | 69SS |  |  |  |  |  | 24d | 0d |  | René | 40h |  |
| 72 | 5.4.2 | Review deployment plan with participants |  | 1d | 2013-05-06 | 2013-05-06 | 71 |  |  |  |  |  | 24d | 0d |  | René | 8h |  |
| 73 | 5.4.3 | Create registration support plan |  | 5d | 2013-05-07 | 2013-05-13 | 72 |  |  |  |  |  | 24d |  |  | René | 40h |  |
| 74 | 5.5 | Go-live | milestone | 0d | 2013-05-21 | 2013-05-21 | 69FS+2d |  |  | 2013-05-28 | 2013-05-28 | 0d | 18d | 0d |  | René |  |  |
| 75 | 5.6 | Prod smoke test | milestone | 0d | 2013-05-21 | 2013-05-21 | 74 |  |  |  |  |  | 18d |  |  | Peter |  |  |
| 76 | 5.7 | Registration opens | milestone | 0d | 2013-06-03 | 2013-06-03 |  |  |  |  |  |  | 0d |  | start no earlier than 2013-06-03 | Peter |  |  |
| 77 | 5.8 | Registration support |  | 10d | 2013-06-03 | 2013-06-14 | 76 |  |  |  |  |  | 0d |  |  | René | 80h |  |

| ID | WBS | Task | Type | Duration | Start | Finish | Predecessors | Complete | Remaining | Total slack | Free slack | Constraint | Resources | Work | Actual work |
| --- | --- | --- | --- | --- | --- | --- | --- | --- | --- | --- | --- | --- | --- | --- | --- |
| 78 | 6 | **Notes Utility Beta** |  | 80d | 2013-02-25 A | 2013-06-14 |  | 29% | 56.61d | 0d |  |  |  | 512h | 176h |
| 79 | 6.1 | **Functional Specs** |  | 26.25d | 2013-02-25 A | 2013-04-02 |  | 99% | 0.29d | 18.75d |  |  |  | 178h | 176h |
| 80 | 6.1.1 | Write functional specs |  | 17d | 2013-02-25 A | 2013-03-19 A |  | 100% |  |  |  |  | Seth | 136h | 136h |
| 81 | 6.1.2 | Have team review of functional specs |  | 0.25d | 2013-03-22 A | 2013-03-22 A | 80FS+2d | 100% |  |  |  |  | Seth | 2h | 2h |
| 82 | 6.1.3 | Get sponsor approval on functional spec |  | 5d | 2013-03-26 A | 2013-04-02 | 81FS+2d | 95% | 0.25d | 18.75d | 0d |  | René | 40h | 38h |
| 83 | 6.1.4 | Functional specs complete | milestone | 0d | 2013-04-02 | 2013-04-02 | 82 |  |  | 18.75d | 0d |  | Seth |  |  |
| 84 | 6.2 | Development |  | 17d | 2013-04-03 | 2013-04-26 | 62, 83 |  |  | 17d | 0d |  | Felicia | 136h |  |
| 85 | 6.3 | UAT |  | 15d | 2013-04-29 | 2013-05-17 | 84 |  |  | 17d | 0d |  | Peter [25%] | 30h |  |
| 86 | 6.4 | **Deployment Preparation** |  | 11d | 2013-04-29 | 2013-05-13 |  |  |  | 24d |  |  |  | 88h |  |
| 87 | 6.4.1 | Create deployment plan |  | 5d | 2013-04-29 | 2013-05-03 | 71SS |  |  | 24d | 0d |  | René | 40h |  |
| 88 | 6.4.2 | Review deployment plan with participants |  | 1d | 2013-05-06 | 2013-05-06 | 87 |  |  | 24d | 0d |  | René | 8h |  |
| 89 | 6.4.3 | Create registration support plan |  | 5d | 2013-05-07 | 2013-05-13 | 88 |  |  | 24d |  |  | René | 40h |  |
| 90 | 6.5 | Go-live | milestone | 0d | 2013-05-21 | 2013-05-21 | 85FS+2d |  |  | 18d | 0d |  | René |  |  |
| 91 | 6.6 | Prod smoke test | milestone | 0d | 2013-05-21 | 2013-05-21 | 90 |  |  | 18d |  |  | Peter |  |  |
| 92 | 6.7 | Registration opens | milestone | 0d | 2013-06-03 | 2013-06-03 |  |  |  | 0d |  | start no earlier than 2013-06-03 | Peter |  |  |
| 93 | 6.8 | Registration support |  | 10d | 2013-06-03 | 2013-06-14 | 92 |  |  | 0d |  |  | René | 80h |  |
